# GD-08 - meerdere dakvlakken

Schedule from MS Project, 2003-01-12 to 2003-02-10, status date 2003-01-08.
BAM Nelissen Van Egteren

## Calendars

- ALLEEN WERKDAGEN: Mon-Fri 08:30-12:30, 13:00-17:00; Sat-Sun off. Exceptions (off unless hours are given): 2003-01-11 to 2003-01-12 08:30-12:30, 13:00-17:00, 2003-01-18 to 2003-01-19 08:30-12:30, 13:00-17:00, 2003-01-25 to 2003-01-26 08:30-12:30, 13:00-17:00, 2003-02-01 to 2003-02-02 08:30-12:30, 13:00-17:00, 2003-02-08 to 2003-02-09 08:30-12:30, 13:00-17:00.

## Schedule

| ID | WBS | Task | Type | Duration | Start | Finish | Predecessors | Total slack |
| --- | --- | --- | --- | --- | --- | --- | --- | --- |
| 1 | 1 | **GEVEL/DAK FASE** |  | 30d | 2003-01-12 | 2003-02-10 |  | 0d |
| 2 | 1.1 | platdak boeiboord constructie |  | 5d | 2003-01-12 | 2003-01-16 |  | 0d |
| 3 | 1.2 | platdak balklaag+ravelingen |  | 5d | 2003-01-16 | 2003-01-20 | 2SS+4d | 0d |
| 4 | 1.3 | platdak dakplaten leggen |  | 4d | 2003-01-20 | 2003-01-23 | 3SS+4d | 0d |
| 5 | 1.4 | schuindak dakgordingen leggen |  | 4d | 2003-01-23 | 2003-01-26 | 4SS+3d | 0d |
| 6 | 1.5 | schuindak dakelementen leggen |  | 4d | 2003-01-26 | 2003-01-29 | 5SS+3d | 0d |
| 7 | 1.6 | dakgoten+ dakranden maken |  | 4d | 2003-01-29 | 2003-02-01 | 6SS+3d | 0d |
| 8 | 1.7 | platdak dakisolatie aanbrengen |  | 4d | 2003-02-01 | 2003-02-04 | 7SS+3d | 0d |
| 9 | 1.8 | platdak dakbedekking aanbr. |  | 4d | 2003-02-04 | 2003-02-07 | 8SS+3d | 0d |
| 10 | 1.9 | schuindak dakbedekking aanbr. |  | 4d | 2003-02-07 | 2003-02-10 | 9SS+3d | 0d |
| 11 | 1.10 | start afbouw fase | milestone | 0d | 2003-02-10 | 2003-02-10 | 10SS+4d | 0d |
